# Gantt Chart

Schedule from MS Project, 2010-09-03 to 2010-12-10, A marks actual dates.
Michigan State University College of Engineering

## Calendars

- Standard: Mon-Fri 08:00-12:00, 13:00-17:00; Sat-Sun off.

## Resources

| Resource |
| --- |
| Emmett |
| Pascha |
| Tom |
| Chad |
| Jeff |
| Fatoumata |
| Team 3 |
| Emmet |
| Fatourmata |

## Schedule

| ID | WBS | Task | Duration | Start | Finish | Predecessors | Complete | Remaining | Total slack | Free slack | Constraint | Resources | Work | Actual work |
| --- | --- | --- | --- | --- | --- | --- | --- | --- | --- | --- | --- | --- | --- | --- |
| 1 | 1 | **Project Deliverables** | 71d? | 2010-09-03 A | 2010-12-10 |  | 32% | 48.58d? | 0d |  |  | Team 3 | 2864h | 1141.33h |
| 2 | 1.1 | **Definition and Startup** | 23.67d? | 2010-09-03 A | 2010-10-06 |  | 99% | 0d? | 0d |  |  | Team 3 | 925.33h | 673.33h |
| 3 | 1.1.1 | **Initial Meetings** | 6d? | 2010-09-03 A | 2010-09-10 A |  | 100% |  |  |  |  | Team 3 | 112h | 112h |
| 4 | 1.1.1.1 | First Team Meeting | 0.17d? | 2010-09-03 A | 2010-09-03 A |  | 100% |  |  |  | start no earlier than 2010-09-03 | Chad; Emmett; Fatoumata; Jeff; Pascha; Tom | 8h | 8h |
| 5 | 1.1.1.2 | Meeting With Xilinx | 1d? | 2010-09-10 A | 2010-09-10 A | 4 | 100% |  |  |  | start no earlier than 2010-09-10 | Chad; Pascha; Emmett; Fatoumata; Jeff; Tom | 48h | 48h |
| 6 | 1.1.1.3 | Meeting With Facilitator | 1d | 2010-09-10 A | 2010-09-10 A | 4, 5 | 100% |  |  |  | start no earlier than 2010-09-10 | Emmett; Pascha; Tom; Chad; Jeff; Fatoumata | 48h | 48h |
| 7 | 1.1.2 | **Initial Setup (Computer and System)** | 17.67d? | 2010-09-13 A | 2010-10-06 | 3 | 99% | 0d? | 0d |  |  | Emmett; Jeff; Chad | 624h | 560h |
| 8 | 1.1.2.1 | Initial Purchase Order (Adapter) | 3d? | 2010-09-15 A | 2010-09-17 A |  | 100% |  |  |  | finish no earlier than 2010-09-17 | Emmett | 24h | 24h |
| 9 | 1.1.2.2 | Install basic necessary software for laptop (Matlab, MS Project, etc) | 15d? | 2010-09-13 A | 2010-10-01 A |  | 100% |  |  |  | finish no earlier than 2010-09-24 | Jeff; Chad; Emmett | 360h | 360h |
| 10 | 1.1.2.3 | Get Software from Xilinx (System Generator) | 16.67d? | 2010-09-13 A | 2010-10-05 A |  | 100% |  |  |  | finish no earlier than 2010-10-01 | Jeff [80%]; Pascha [20%] | 128h | 128h |
| 11 | 1.1.2.4 | Get Xilinx (Demo) Package Running | 1d? | 2010-10-05 A | 2010-10-06 A | 9, 10, 8 | 100% |  |  |  | finish no earlier than 2010-10-05 | Pascha; Jeff; Chad | 24h | 24h |
| 12 | 1.2 | **Design** | 55d? | 2010-09-13 A | 2010-11-26 | 3 | 20% | 44.09d? | 0d |  |  |  | 1370.67h | 466.67h |
| 13 | 1.2.1 | Proposed Project Direction | 15d? | 2010-09-13 A | 2010-10-01 A | 3 | 100% |  |  |  | finish no earlier than 2010-10-01 | Team 3 | 120h | 120h |
| 14 | 1.2.2 | Final Project Algorithm Direction (future system testing may change this) | 5d? | 2010-10-04 | 2010-10-08 | 13 |  |  | 5d | 0d |  | Team 3 | 40h |  |
| 15 | 1.2.3 | **Research** | 35.67d? | 2010-09-13 A | 2010-11-01 |  | 31% | 24.76d? | 19.33d |  |  |  | 1210.67h | 346.67h |
| 16 | 1.2.3.1 | OpenCV | 15d? | 2010-09-13 A | 2010-10-01 A |  | 100% |  |  |  | start no earlier than 2010-09-13 | Fatoumata; Tom | 240h | 240h |
| 17 | 1.2.3.2 | Xilinx Software | 5d? | 2010-09-13 A | 2010-09-17 A |  | 100% |  |  |  | start no earlier than 2010-09-13 | Jeff; Chad | 80h | 80h |
| 18 | 1.2.3.3 | MATLAB/Simulink | 5d? | 2010-10-04 | 2010-10-08 |  |  |  | 35d |  | finish no earlier than 2010-10-08 | Chad; Tom; Pascha; Jeff | 160h |  |
| 19 | 1.2.3.4 | Edge Detection | 3.33d? | 2010-10-05 A | 2010-10-08 A |  | 100% |  |  |  | finish no earlier than 2010-10-08 | Team 3 | 26.67h | 26.67h |
| 20 | 1.2.3.5 | FPGA | 6.67d? | 2010-09-30 | 2010-10-08 |  |  |  | 35d |  | finish no earlier than 2010-10-08 | Team 3 | 53.33h |  |
| 21 | 1.2.3.6 | Spartan-3A | 3.33d? | 2010-09-13 | 2010-09-16 |  |  |  | 51.67d |  |  | Team 3 | 26.67h |  |
| 22 | 1.2.3.7 | Object Detection | 20d? | 2010-09-13 | 2010-10-08 |  |  |  | 35d |  | finish no earlier than 2010-10-08 | Tom; Pascha; Jeff | 480h |  |
| 23 | 1.2.3.8 | Camera Testing/Gather Data | 18d? | 2010-10-06 | 2010-11-01 | 11 |  |  | 19.33d |  | finish no earlier than 2010-10-08 | Team 3 | 144h |  |
| 24 | 1.2.4 | **Design Algorithms (continual testing throughout process)** | 25d? | 2010-10-11 | 2010-11-12 | 14 |  |  | 5d | 0d |  |  |  |  |
| 25 | 1.2.4.1 | Edge Detection | 16d? | 2010-10-11 | 2010-11-01 |  |  |  | 14d |  | start no earlier than 2010-10-08 |  |  |  |
| 26 | 1.2.4.2 | Morphological | 20d? | 2010-10-11 | 2010-11-05 |  |  |  | 10d |  | start no earlier than 2010-10-11 |  |  |  |
| 27 | 1.2.4.3 | Object Detection | 25d? | 2010-10-11 | 2010-11-12 |  |  |  | 5d |  | finish no earlier than 2010-11-12 |  |  |  |
| 28 | 1.2.4.4 | Object Classification | 25d? | 2010-10-11 | 2010-11-12 |  |  |  | 5d |  | finish no earlier than 2010-11-12 |  |  |  |

| ID | WBS | Task | Duration | Start | Finish | Predecessors | Complete | Remaining | Total slack | Free slack | Constraint | Deadline | Resources | Work | Actual work |
| --- | --- | --- | --- | --- | --- | --- | --- | --- | --- | --- | --- | --- | --- | --- | --- |
| 29 | 1.2.5 | **System Implementation and Final Testing** | 10d? | 2010-11-15 | 2010-11-26 | 24 |  |  | 0d |  |  |  |  |  |  |
| 30 | 1.2.5.1 | Link algorithms/implement as a single system | 5d? | 2010-11-15 | 2010-11-19 |  |  |  | 5d |  | start no earlier than 2010-11-15 |  |  |  |  |
| 31 | 1.2.5.2 | Test accuracy of the system | 5d? | 2010-11-22 | 2010-11-26 |  |  |  | 0d |  | finish no earlier than 2010-11-26 |  |  |  |  |
| 32 | 1.2.5.3 | Load algorithms onto FPGA | 1d? | 2010-11-26 | 2010-11-26 |  |  |  | 0d |  | start no earlier than 2010-11-26 |  |  |  |  |
| 33 | 1.3 | Cushion Time | 9d? | 2010-11-29 | 2010-12-09 | 12 |  |  | 0d |  | start no earlier than 2010-11-29 |  |  |  |  |
| 34 | 1.4 | Design Day | 1d | 2010-12-10 | 2010-12-10 | 33 |  |  | 0d |  | finish no later than 2010-12-10 | 2010-12-10 |  |  |  |
| 35 | 2 | **Classroom Deliverables** | 60d? | 2010-09-20 A | 2010-12-10 |  | 24% | 45.58d? | 0d |  |  |  |  | 992h | 565.34h |
| 36 | 2.1 | Website Creation | 5d? | 2010-10-04 A | 2010-10-08 A | 13 | 100% |  |  |  | start no earlier than 2010-09-13 |  | Fatoumata | 40h | 40h |
| 37 | 2.2 | Team Technical Presentation | 10d? | 2010-10-25 | 2010-11-05 |  |  |  | 25d |  | start no earlier than 2010-10-25 |  | Team 3 | 80h |  |
| 38 | 2.3 | 2nd Demonstration of Progress | 28d? | 2010-10-13 | 2010-11-19 |  |  |  | 15d |  | start no earlier than 2010-10-13 |  |  |  |  |
| 39 | 2.4 | Final Reports Due to Shanblatt | 10d? | 2010-11-22 | 2010-12-03 |  |  |  | 5d |  | start no earlier than 2010-11-22 |  |  |  |  |
| 40 | 2.5 | Progress Report | 5d? | 2010-10-25 | 2010-10-29 |  |  |  | 30d |  | start no earlier than 2010-10-25 |  |  |  |  |
| 41 | 2.6 | Poster | 15d? | 2010-11-22 | 2010-12-10 |  |  |  | 0d |  | start no earlier than 2010-11-22 |  |  |  |  |
| 42 | 2.7 | **Preproposal** | 10d? | 2010-09-20 A | 2010-10-01 |  | 89% | 1.11d? | 50d | 0d |  |  | Pascha; Emmett; Tom | 392h | 357.33h |
| 43 | 2.7.1 | 1st Draft | 5d? | 2010-09-20 A | 2010-09-24 A |  | 100% |  |  |  | finish no earlier than 2010-09-24 |  | Pascha [50%]; Emmett [25%]; Tom [25%] | 120h | 120h |
| 44 | 2.7.2 | Group Review | 1d | 2010-09-27 | 2010-09-27 | 43 |  |  | 54d |  | start no earlier than 2010-09-24 |  | Team 3 | 8h |  |
| 45 | 2.7.3 | Final Draft | 3d? | 2010-09-29 A | 2010-10-01 A | 44 | 100% |  |  |  | finish no earlier than 2010-10-01 |  | Pascha | 24h | 24h |
| 46 | 2.8 | **Proposal** | 14d? | 2010-10-04 | 2010-10-21 | 42 |  |  | 36d |  |  |  |  | 192h |  |
| 47 | 2.8.1 | 1st Draft | 5d? | 2010-10-04 | 2010-10-08 |  |  |  | 41d | 0d | finish no earlier than 2010-09-24 |  | Pascha; Emmett; Tom | 120h |  |
| 48 | 2.8.2 | Group Review | 6d | 2010-10-11 | 2010-10-18 | 47 |  |  | 36d | 0d | start no earlier than 2010-09-24 |  | Team 3 | 48h |  |
| 49 | 2.8.3 | Final Draft | 3d? | 2010-10-19 | 2010-10-21 | 48 |  |  | 36d |  | finish no earlier than 2010-10-01 |  | Pascha | 24h |  |
| 50 | 2.9 | **Oral Presentation of Project Overview** | 21d? | 2010-09-29 A | 2010-10-27 |  | 58% | 8.88d? | 32d |  |  |  |  | 232h | 144h |
| 51 | 2.9.1 | 1st Draft | 3d? | 2010-09-29 A | 2010-10-01 A |  | 100% |  |  |  | finish no earlier than 2010-10-01 |  | Emmett; Tom | 48h | 48h |
| 52 | 2.9.2 | Group Review | 6d? | 2010-10-01 A | 2010-10-08 A |  | 100% |  |  |  | start no earlier than 2010-10-01 |  | Team 3 | 48h | 48h |
| 53 | 2.9.3 | Practice to Facilitator | 6d? | 2010-10-08 A | 2010-10-15 A |  | 100% |  |  |  | start no earlier than 2010-10-08 |  | Team 3 | 48h | 48h |
| 54 | 2.9.4 | Oral Presentation final draft | 5d? | 2010-10-11 | 2010-10-15 |  |  |  | 40d |  | start no earlier than 2010-10-11 |  | Emmett | 40h |  |
| 55 | 2.9.5 | Presentation to Class | 6d? | 2010-10-20 | 2010-10-27 |  |  |  | 32d |  | start no earlier than 2010-10-20 |  | Team 3 | 48h |  |
| 56 | 2.10 | Six Sigma HW #1 - Voice of Customer | 3d? | 2010-09-27 A | 2010-09-29 A |  | 100% |  |  |  | start no earlier than 2010-09-27 |  | Team 3 | 24h | 24h |
| 57 | 2.11 | Six Sigma HW #2-Project Function | 4d? | 2010-10-06 | 2010-10-11 |  |  |  | 44d |  | finish no earlier than 2010-10-11 |  | Team 3 | 32h |  |
